# AER CAXIAS DO SUL RS-GRL-AP-PROJ-001-00

Schedule from MS Project, 2018-01-01 to 2019-08-15, status date 2014-11-07.

## Calendars

- Calendário Dias Corridos: Mon-Sun 09:00-12:00, 13:00-18:00.

## Resources

| Resource |
| --- |
| MÊS 01 |
| MÊS 02 |
| MÊS 03 |
| MÊS 02,5 |
| MÊS 04 |
| MÊS 05 |
| MÊS 0,5 |
| MÊS 1,5 |
| MÊS 2,5 |
| MÊS 3,5 |

## Schedule

| ID | WBS | Task | Type | Duration | Start | Finish | Predecessors | Total slack | Constraint |
| --- | --- | --- | --- | --- | --- | --- | --- | --- | --- |
| 1 | 1 | **ETAPA PARCIAL** |  | 592d | 2018-01-01 | 2019-08-15 |  | 0d |  |
| 2 | 1.1 | **SERVIÇOS PRELIMINARES** |  | 592d | 2018-01-01 | 2019-08-15 |  | 0d |  |
| 3 | 1.1.1 | **SERVIÇOS INICIAIS** |  | 592d | 2018-01-01 | 2019-08-15 |  | 0d |  |
| 4 | 1.1.1.1 | MOBILIZAÇÃO DO CANTEIRO DE OBRAS |  | 30d | 2018-01-01 | 2018-01-30 |  | 0d | start no earlier than 2018-01-01 |
| 5 | 1.1.1.2 | PLACA DA OBRA |  | 15d | 2018-01-01 | 2018-01-15 | 4SS | 0d |  |
| 6 | 1.1.1.3 | REMOÇÃO TAPUME DA OBRA EXISTENTE |  | 5d | 2018-01-01 | 2018-01-05 | 4SS | 0d |  |
| 7 | 1.1.1.4 | TAPUME DA OBRA |  | 5d | 2018-01-06 | 2018-01-10 | 6 | 0d |  |
| 8 | 1.1.1.5 | PORTÃO DE AÇO PARA ACESSO DE PEDESTRES E VEÍCULOS |  | 2d | 2018-01-06 | 2018-01-07 | 7SS | 0d |  |
| 9 | 1.1.1.6 | ALUGUEL DE CONTAINER/SANIT COM 4 VASOS/1 LAVAT/1 MIC/4 CHUV (LARG=2,20 COMP=6,20M ALT=2,50M - 08 UNIDADES) |  | 592d | 2018-01-01 | 2019-08-15 | 4SS | 0d |  |
| 10 | 1.1.1.7 | ALUGUEL DE CONTAINER PARA ESCRITORIO, SEM DIVISORIAS INTERNAS E SEM SANITARIO (LARG=2,20 COMP=6,20M ALT=2,50M - 43 UNIDADES) |  | 592d | 2018-01-01 | 2019-08-15 | 4SS | 0d |  |
| 11 | 1.1.1.8 | ALUGUEL DE CONTAINER COM PARA ESCRITORIO, COMPLETO, SEM DIVISORIAS INTERNAS, COM 1 VASOS/1 LAVAT/1 CHUV (LARG=2,20 COMP=6,20M ALT=2,50M - 08 UNIDADE) |  | 592d | 2018-01-01 | 2019-08-15 | 4SS | 0d |  |
| 12 | 1.1.1.9 | GALPAO ABERTO EM CANTEIRO DE OBRA (CARPINTARIA, CENTRAL DE ARMAÇÃO, OFICINA, ETC.) C/ TELHA ONDULADA 6MM, ESTRUTURA EM MADEIRA, INCLUINDO PISO CIMENTADO COM PREPARO DO TERRENO |  | 592d | 2018-01-01 | 2019-08-15 | 4SS | 0d |  |
| 13 | 1.1.1.10 | ENTRADA DE ENERGIA ELETRICA/TELEFONE |  | 5d | 2018-01-01 | 2018-01-05 | 4SS | 0d |  |
| 14 | 1.1.1.11 | LIGAÇÃO DOMICILIAR DE ESGOTO |  | 5d | 2018-01-01 | 2018-01-05 | 4SS | 0d |  |
| 15 | 1.1.1.12 | LIGAÇÃO DOMICILIAR DE AGUA |  | 5d | 2018-01-01 | 2018-01-05 | 4SS | 0d |  |
| 16 | 1.1.1.13 | LIMPEZA PERMANENTE |  | 592d | 2018-01-01 | 2019-08-15 | 4SS | 0d |  |
| 17 | 1.1.1.14 | MANUTENÇÃO CANTEIRO DE OBRAS |  | 592d | 2018-01-01 | 2019-08-15 | 4SS | 0d |  |
| 18 | 1.1.1.15 | ARRUAMENTO EM BRITA 2 PARA ACESSO DE OBRA |  | 3d | 2018-01-01 | 2018-01-03 | 4SS | 0d |  |
| 19 | 1.1.1.16 | REMANEJAMENTO DE REDE DE DRENAGEM PLUVIAL EM TUBO DE CONCRETO DN 300MM, SEM REAPROVEITAMENTO |  | 10d | 2018-01-08 | 2018-01-17 | 4SS+7d | 0d |  |
| 20 | 1.1.1.17 | FORNECIMENTO E INSTALAÇÃO DE CAIXA DE AREIA, EM ALVENARIA, DIMENSÕES INTERNAS 200X200CM,PROFUNDIDADE 200 CM,INCLUINDO TAMPA PRÉ-MOLDADA DE CONCRETO E FUNDO DE CONCRETO 15MPA TIPO C |  | 3d | 2018-01-13 | 2018-01-15 | 19SS+5d | 0d |  |
| 21 | 1.1.2 | **SERVIÇOS GERAIS** |  | 592d | 2018-01-01 | 2019-08-15 |  | 0d |  |
| 22 | 1.1.2.1 | LOCACAO DA OBRA, COM USO DE EQUIPAMENTOS TOPOGRAFICOS (TERRAPLENAGEM) |  | 10d | 2018-01-26 | 2018-02-04 | 152SS-5d | 0d |  |
| 23 | 1.1.2.2 | LOCACAO DA OBRA, COM USO DE EQUIPAMENTOS TOPOGRAFICOS, INCLUSIVE NIVELADOR - EDIFICAÇÃO |  | 415d | 2018-02-27 | 2019-04-17 | 159SS-3d | 0d |  |
| 24 | 1.1.2.3 | CARGA, MANOBRAS E DESCARGA DE MATERIAIS DIVERSOS, COM CAMINHAO BASCULANTE 6M3 (CARGA E DESCARGA MANUAIS) |  | 592d | 2018-01-01 | 2019-08-15 | 4SS | 0d |  |
| 25 | 1.1.2.4 | TRANSPORTE DE MATERIAL DE LIMPEZA DE TERRENO (DMT=20KM) |  | 592d | 2018-01-01 | 2019-08-15 | 16SS | 0d |  |
| 26 | 1.1.2.5 | REMOÇÃO DE AÇO EXISTENTE NO TERREO BLOCO C |  | 2d | 2018-01-06 | 2018-01-07 | 4SS+5d | 0d |  |
| 27 | 1.1.2.6 | LOCACAO MENSAL DE ANDAIME METALICO TIPO FACHADEIRO (MONTAGEM E DESMONTAGEM) - BLOCO B E C |  | 394d | 2018-04-03 | 2019-05-01 | 255SS | 0d |  |
| 28 | 1.1.2.7 | LOCACAO DE ANDAIME METALICO TUBULAR TIPO TORRE - BLOCO B |  | 330d | 2018-06-22 | 2019-05-17 | 185SS | 0d |  |
| 29 | 1.1.2.8 | LOCACAO MENSAL DE ANDAIME METALICO TIPO FACHADEIRO (MONTAGEM E DESMONTAGEM) - BLOCO C |  | 288d | 2018-04-03 | 2019-01-15 | 255SS | 0d |  |
| 30 | 1.1.2.9 | ESGOTAMENTO COM BOMBAS | manual | 90d | 2018-02-01 | 2018-05-01 |  |  |  |
| 31 | 1.1.2.10 | POSTE DE ILUMINAÇÃO COM 04 LUMINÁRIAS 400W |  | 3d | 2018-01-06 | 2018-01-08 | 13 | 0d |  |
| 32 | 1.1.2.11 | DEMOLIÇÃO DE CONCRETO SIMPLES COM MARTELETE E COMPRESSOR (USINA DE CONCRETO E PEDRAS DE CONCRETO) |  | 5d | 2018-01-16 | 2018-01-20 | 4SS+15d | 0d |  |
| 33 | 1.1.2.12 | DEMOLIÇÃO ESTRUTURA DE ALVENARIA (CASA DE APOIO ENTRE O BOLOCO C E B) |  | 5d | 2018-01-16 | 2018-01-20 | 4SS+15d | 0d |  |
| 34 | 1.1.2.13 | LIMPEZA DE FERRAGEM |  | 5d | 2018-01-16 | 2018-01-20 | 4SS+15d | 0d |  |
| 35 | 1.1.2.14 | BANDEJA SALVA-VIDAS/COLETA DE ENTULHOS, COM TABUA - EPC |  | 3d | 2018-06-22 | 2018-06-24 | 179 | 0d |  |
| 36 | 1.1.2.15 | PLACA DE SINALIZACAO DE SEGURANCA CONTRA INCENDIO - FORNECIMENTO E INSTALAÇÃO - EPC |  | 3d | 2018-01-01 | 2018-01-03 | 9SS, 10SS, 11SS, 12SS | 0d |  |
| 37 | 1.1.2.16 | EXTINTOR INCENDIO TP GAS CARBONICO 6KG - EPC |  | 3d | 2018-01-01 | 2018-01-03 | 9SS, 10SS, 11SS, 12SS | 0d |  |
| 38 | 1.1.2.17 | EXTINTOR INCENDIO AGUA-PRESSURIZADA 10L - EPC |  | 3d | 2018-01-01 | 2018-01-03 | 9SS, 10SS, 11SS, 12SS | 0d |  |
| 39 | 1.1.2.18 | PASSADICOS DE MADEIRA PARA PEDESTRES - EPC |  | 172d | 2018-01-31 | 2018-07-21 | 152SS | 0d |  |
| 40 | 1.1.2.19 | GUARDA CORPO DE MADEIRA E CORDA DE SISAL - BLOCO B E C - EPC |  | 418d | 2018-03-26 | 2019-05-17 | 167SS | 0d |  |
| 41 | 1.1.2.20 | TELA DE NYLON PARA PROTEÇÃO DE FACHADA E RODAPÉ DE PROTEÇÃO PARA ANDAIME FACHADEIRO - BLOCO B - EPC |  | 418d | 2018-03-26 | 2019-05-17 | 167SS | 0d |  |
| 42 | 1.1.2.21 | TELA DE NYLON PARA PROTEÇÃO DE FACHADA E RODAPÉ DE PROTEÇÃO PARA ANDAIME FACHADEIRO - BLOCO C - EPC |  | 418d | 2018-03-26 | 2019-05-17 | 167SS | 0d |  |
| 43 | 1.1.2.22 | FECHAMENTO PROVISORIO DE VÃOS DE ELEVADORES EM CHAPA MADEIRA COMPENSADA - EPC |  | 508d | 2018-03-26 | 2019-08-15 | 167SS | 0d |  |
| 44 | 1.1.2.23 | PROTETOR DE VERGALHÃO- EPC |  | 442d | 2018-03-02 | 2019-05-17 | 159SS | 0d |  |

Notes:
- 27: MULTIPLICAR DURAÇÃO POR QTDD UND.
- 28: MULTIPLICAR DURAÇÃO POR QTDD UND.
- 29: MULTIPLICAR DURAÇÃO POR QTDD UND.

| ID | WBS | Task | Duration | Start | Finish | Predecessors | Total slack |
| --- | --- | --- | --- | --- | --- | --- | --- |
| 45 | 1.1.3 | **EQUIPE TÉCNICA ADMINISTRATIVA DA OBRA** | 592d | 2018-01-01 | 2019-08-15 |  | 0d |
| 46 | 1.1.3.1 | COORDENADOR SÉNIOR GERAL DE OBRA (ENGENHEIRO SÉNIOR) (X1) | 592d | 2018-01-01 | 2019-08-15 | 4SS | 0d |
| 47 | 1.1.3.2 | ENGENHEIRO SÉNIOR DE PLANEJAMENTO, CONTROLE E RISCO (X1) | 592d | 2018-01-01 | 2019-08-15 | 4SS | 0d |
| 48 | 1.1.3.3 | ENGENHEIRO DE OBRA SÉNIOR DO BLOCO B (X1) | 445d | 2018-02-28 | 2019-05-18 | 154SS | 0d |
| 49 | 1.1.3.4 | ENGENHEIRO DE OBRA SÉNIOR DO BLOCO C (X1) | 412d | 2018-01-03 | 2019-02-18 | 232SS | 0d |
| 50 | 1.1.3.5 | ENGENHEIRO DE OBRA PLENO (X1) | 592d | 2018-01-01 | 2019-08-15 | 4SS | 0d |
| 51 | 1.1.3.6 | ENGENHEIRO ELETRICISTA (1X) | 428d | 2018-03-02 | 2019-05-03 | 157SS | 0d |
| 52 | 1.1.3.7 | ENGENHEIRO DE OBRA SÉNIOR - COORDENADOR SERVIÇOS BIM (X1) | 592d | 2018-01-01 | 2019-08-15 | 4SS | 0d |
| 53 | 1.1.3.8 | ENGENHEIRO DE SÉNIOR - PLANEJAMENTO DA OBRA EM NAVISWORKS (X1) | 592d | 2018-01-01 | 2019-08-15 | 4SS | 0d |
| 54 | 1.1.3.9 | ARQUITETO SÉNIOR BIM BLOCO B (X1) | 445d | 2018-02-28 | 2019-05-18 | 154SS | 0d |
| 55 | 1.1.3.10 | ARQUITETO SÉNIOR BIM BLOCO C (X1) | 412d | 2018-01-03 | 2019-02-18 | 232SS | 0d |
| 56 | 1.1.3.11 | TOPÓGRAFO (X1) | 592d | 2018-01-01 | 2019-08-15 | 4SS | 0d |
| 57 | 1.1.3.12 | AUXILIAR DE TOPÓGRAFO (X1) | 592d | 2018-01-01 | 2019-08-15 | 4SS | 0d |
| 58 | 1.1.3.13 | ENGENHEIRO DE SEGURANÇA DO TRABALHO (X1) | 592d | 2018-01-01 | 2019-08-15 | 4SS | 0d |
| 59 | 1.1.3.14 | TECNICO DE SEGURANÇA DO TRAB. (X2) | 592d | 2018-01-01 | 2019-08-15 | 4SS | 0d |
| 60 | 1.1.3.15 | MÉDICO DO TRABALHO (X1) | 592d | 2018-01-01 | 2019-08-15 | 4SS | 0d |
| 61 | 1.1.3.16 | MESTRE DE OBRAS - GERAL DA OBRA (X1) | 592d | 2018-01-01 | 2019-08-15 | 4SS | 0d |
| 62 | 1.1.3.17 | MESTRE DE OBRAS - BLOCO C (X1) | 412d | 2018-01-03 | 2019-02-18 | 232SS | 0d |
| 63 | 1.1.3.18 | MESTRE DE OBRAS - BLOCO B (X1) | 445d | 2018-02-28 | 2019-05-18 | 154SS | 0d |
| 64 | 1.1.3.19 | ENCARREGADO GERAL - SERVIÇOS GERAIS DA OBRA (X1) | 592d | 2018-01-01 | 2019-08-15 | 4SS | 0d |
| 65 | 1.1.3.20 | ENCARREGADO GERAL - FÔRMA/CIMBRAMENTO DO BLOCO B (X1) | 445d | 2018-02-28 | 2019-05-18 | 154SS | 0d |
| 66 | 1.1.3.21 | ENCARREGADO GERAL - FÔRMA/CIMBRAMENTO DO BLOCO C (X1) | 412d | 2018-01-03 | 2019-02-18 | 232SS | 0d |
| 67 | 1.1.3.22 | ENCARREGADO GERAL - ARMAÇÃO E PROTENÇÃO DO BLOCO B (X1) | 445d | 2018-02-28 | 2019-05-18 | 154SS | 0d |
| 68 | 1.1.3.23 | ENCARREGADO GERAL - ARMAÇÃO E PROTENÇÃO DO BLOCO C (X1) | 412d | 2018-01-03 | 2019-02-18 | 232SS | 0d |
| 69 | 1.1.3.24 | ENCARREGADO GERAL - CONCRETAGEM DO BLOCO B (X1) | 445d | 2018-02-28 | 2019-05-18 | 154SS | 0d |
| 70 | 1.1.3.25 | ENCARREGADO GERAL - CONCRETAGEM DO BLOCO C (X1) | 412d | 2018-01-03 | 2019-02-18 | 232SS | 0d |
| 71 | 1.1.3.26 | ENCARREGADO GERAL - LIMPEZA GERAL (X1) | 592d | 2018-01-01 | 2019-08-15 | 4SS | 0d |
| 72 | 1.1.3.27 | APONTADOR (X2) | 592d | 2018-01-01 | 2019-08-15 | 4SS | 0d |
| 73 | 1.1.3.28 | FERRAMENTEIRO (X2) | 592d | 2018-01-01 | 2019-08-15 | 4SS | 0d |
| 74 | 1.1.3.29 | ALMOXARIFE (X1) | 592d | 2018-01-01 | 2019-08-15 | 4SS | 0d |
| 75 | 1.1.3.30 | AUXILIAR DE ALMOXARIFADO - GERAL DA OBRA (1X) | 592d | 2018-01-01 | 2019-08-15 | 4SS | 0d |
| 76 | 1.1.3.31 | AUXILIAR DE ALMOXARIFADO - BLOCO C E B (1X) | 500d | 2018-01-03 | 2019-05-17 | 232SS | 0d |
| 77 | 1.1.3.32 | GESTOR DA QUALIDADE (X1) (AUXILIAR TÉCNICO EM ENGENHARIA) | 592d | 2018-01-01 | 2019-08-15 | 4SS | 0d |
| 78 | 1.1.3.33 | ENCARREGADO FINANCEIRO (X1) | 592d | 2018-01-01 | 2019-08-15 | 4SS | 0d |
| 79 | 1.1.3.34 | ENCARREGADO DE PESSOAL (X1) | 592d | 2018-01-01 | 2019-08-15 | 4SS | 0d |
| 80 | 1.1.3.35 | COMPRADOR (X1) | 592d | 2018-01-01 | 2019-08-15 | 4SS | 0d |
| 81 | 1.1.3.36 | AUXILIAR TÉCNICO (PARA O COORDENADOR PLENO GERAL DE OBRA) - (X1) | 592d | 2018-01-01 | 2019-08-15 | 46SS | 0d |
| 82 | 1.1.3.37 | AUXILIAR TÉCNICO (PARA O ENGENHEIRO SÉNIOR DE PLANEJAMENTO, CONTROLE E RISCO) - (1X) | 592d | 2018-01-01 | 2019-08-15 | 47SS | 0d |
| 83 | 1.1.3.38 | AUXILIAR TÉCNICO (PARA O ENGENHEIRO DE OBRA SÉNIOR DO BLOCO B) - (1X) | 445d | 2018-02-28 | 2019-05-18 | 48SS | 0d |
| 84 | 1.1.3.39 | AUXILIAR TÉCNICO (PARA O ENGENHEIRO DE OBRA SÉNIOR DO BLOCO C) - (1X) | 412d | 2018-01-03 | 2019-02-18 | 49SS | 0d |
| 85 | 1.1.3.40 | AUXILIAR TÉCNICO (PARA O ENGENHEIRO DE OBRA PLENO) - (1X) | 592d | 2018-01-01 | 2019-08-15 | 50SS | 0d |
| 86 | 1.1.3.41 | AUXILIAR TÉCNICO (PARA COORDENADOR BIM) - (1X) | 592d | 2018-01-01 | 2019-08-15 | 52SS | 0d |
| 87 | 1.1.3.42 | TECNICO EDIFICAÇÕES - BLOCO B (1X) | 445d | 2018-02-28 | 2019-05-18 | 154SS | 0d |
| 88 | 1.1.3.43 | TECNICO EDIFICAÇÕES - BLOCO C E SERVIÇOS GERAIS (1X) | 592d | 2018-01-01 | 2019-08-15 | 4SS | 0d |
| 89 | 1.1.3.44 | OPERADOR DE ELEVADOR/GRUA - ELEVADOR BLOCO B (1X) | 90d | 2019-05-18 | 2019-08-15 | 205 | 0d |
| 90 | 1.1.3.45 | OPERADOR DE ELEVADOR/GRUA - GRUA BLOCO B (1X) | 418d | 2018-03-26 | 2019-05-17 | 167SS | 0d |
| 91 | 1.1.3.46 | OPERADOR DE ELEVADOR/GRUA - GRUA BLOCO C (1X) | 305d | 2018-03-20 | 2019-01-18 | 247SS | 0d |
| 92 | 1.1.3.47 | SINALEIRO - GRUA BLOCO B (1X) | 418d | 2018-03-26 | 2019-05-17 | 167SS | 0d |
| 93 | 1.1.3.48 | SINALEIRO - GRUA BLOCO C (1X) | 305d | 2018-03-20 | 2019-01-18 | 247SS | 0d |
| 94 | 1.1.3.49 | SINALEIRO - ELEVADOR BLOCO B (1X) | 90d | 2019-05-18 | 2019-08-15 | 205 | 0d |
| 95 | 1.1.3.50 | VIGILÂNCIA/PORTEIRO (2X) | 592d | 2018-01-01 | 2019-08-15 | 4SS | 0d |
| 96 | 1.1.3.51 | GUARDIÃO NOTURNO (2X) | 592d | 2018-01-01 | 2019-08-15 | 4SS | 0d |
| 97 | 1.1.3.52 | SERVENTE DE APOIO (2X) | 592d | 2018-01-01 | 2019-08-15 | 4SS | 0d |
| 98 | 1.1.3.53 | OPERADOR DE BETONEIRA - GERAL DA OBRA (1X) | 592d | 2018-01-01 | 2019-08-15 | 4SS | 0d |
| 99 | 1.1.3.54 | OPERADOR DE BETONEIRA - BLOCO C E B (1X) | 500d | 2018-01-03 | 2019-05-17 | 232SS | 0d |
| 100 | 1.1.3.55 | MENOR APRENDIZ - CONFORME LEGISLAÇÃO - 5% DE 240 OPERÁRIOS (12 MENORES) | 592d | 2018-01-01 | 2019-08-15 | 4SS | 0d |
| 101 | 1.1.3.56 | SECRETÁRIA (1X) | 592d | 2018-01-01 | 2019-08-15 | 4SS | 0d |
| 102 | 1.1.3.57 | AUXILIAR ESCRITORIO (X1) | 592d | 2018-01-01 | 2019-08-15 | 4SS | 0d |

| ID | WBS | Task | Duration | Start | Finish | Predecessors | Total slack |
| --- | --- | --- | --- | --- | --- | --- | --- |
| 103 | 1.1.4 | **MATERIAIS E CONSUMOS** | 592d | 2018-01-01 | 2019-08-15 |  | 0d |
| 104 | 1.1.4.1 | LICENÇAS, TAXAS E SEGURO DE ENGENHARIA | 1d | 2018-01-03 | 2018-01-03 | 4SS+2d | 0d |
| 105 | 1.1.4.2 | CONSUMOS GERAIS | 592d | 2018-01-01 | 2019-08-15 | 4SS | 0d |
| 106 | 1.1.4.3 | MÓVEIS E UTENSÍLIOS | 592d | 2018-01-01 | 2019-08-15 | 4SS | 0d |
| 107 | 1.1.5 | **ENSAIOS** | 507d | 2018-01-01 | 2019-05-22 |  | 0d |
| 108 | 1.1.5.1 | ENSAIO DE RESISTENCIA A TRACAO NA FLEXAO DE CONCRETO | 428d | 2018-03-02 | 2019-05-03 | 159SS | 0d |
| 109 | 1.1.5.2 | ENSAIO DE RESISTENCIA A COMPRESSAO SIMPLES - CONCRETO | 428d | 2018-03-02 | 2019-05-03 | 159SS | 0d |
| 110 | 1.1.5.3 | ENSAIO DE ABATIMENTO DO TRONCO DE CONE | 428d | 2018-03-02 | 2019-05-03 | 159SS | 0d |
| 111 | 1.1.5.4 | ENSAIO DE RECEBIMENTO E ACEITACAO DE CIMENTO PORTLAND | 428d | 2018-03-02 | 2019-05-03 | 159SS | 0d |
| 112 | 1.1.5.5 | ESTUDO DE DOSAGEM DO CONCRETO | 428d | 2018-03-02 | 2019-05-03 | 159SS | 0d |
| 113 | 1.1.5.6 | ACOMPANHAMENTO DE DOSAGEM DE CONCRETO/CONCRETAGEM/ CONTROLE TECNÓLOGICO DO AÇO | 428d | 2018-03-02 | 2019-05-03 | 159SS | 0d |
| 114 | 1.1.5.7 | ENSAIOS DE AGREGADOS | 428d | 2018-01-01 | 2019-03-04 | 115SS | 0d |
| 115 | 1.1.5.8 | ENSAIOS EM TERRAPLANAGEM | 30d | 2018-01-01 | 2018-01-30 | 152SS-30d | 0d |
| 116 | 1.1.5.9 | SONDAGEM DO TERRENO ROTATIVA (15 METROS) AREA NOVO TUNEL BLOCO C | 5d | 2018-01-01 | 2018-01-05 | 115SS | 0d |
| 117 | 1.1.5.10 | TESTE DE CONTINUIDADE DO SPDA E ATERRAMENTOS | 5d | 2019-05-04 | 2019-05-08 | 157 | 0d |
| 118 | 1.1.5.11 | TESTE DE REDE DE DRENAGEM | 5d | 2019-05-18 | 2019-05-22 | 167, 248 | 0d |
| 119 | 1.1.5.12 | ENSAIO DE VERIFICAÇÃO DE BITOLA | 5d | 2018-01-21 | 2018-01-25 | 34 | 0d |
| 120 | 1.1.5.13 | ENSAIO DE TRAÇÃO EM BARRAS DE AÇO | 5d | 2018-01-21 | 2018-01-25 | 34 | 0d |
| 121 | 1.1.6 | **RELATÓRIOS E PROJETOS** | 592d | 2018-01-01 | 2019-08-15 |  | 0d |
| 122 | 1.1.6.1 | CREA ART | 30d | 2018-01-01 | 2018-01-30 | 4SS | 0d |
| 123 | 1.1.6.2 | PROJETO DE GERÊNCIAMENTO DE RESÍDUOS DA CONSTRUÇÃO CIVIL (CONFORME RESOLUÇÃO 307 DO CONAMA) | 30d | 2018-01-01 | 2018-01-30 | 4SS | 0d |
| 124 | 1.1.6.3 | PROJETO DE SEGURANÇA DO TRABALHO | 30d | 2018-01-01 | 2018-01-30 | 4SS | 0d |
| 125 | 1.1.6.4 | PROGRAMA DE CONDIÇÕES E MEIO AMBIENTE DE TRABALHO - PCMAT | 30d | 2018-01-01 | 2018-01-30 | 4SS | 0d |
| 126 | 1.1.6.5 | PROGRAMA DE CONTROLE MÉDICO DE SÁUDE OCUPACIONAL - PCMSO | 30d | 2018-01-01 | 2018-01-30 | 4SS | 0d |
| 127 | 1.1.6.6 | PROJETO DE DETALHAMENTO EM BIM LOD 500 DA SOLUÇÃO DE PROTENSÃO A SER EXECUTADA CONFORME INDICAÇÕES DE FORNECEDOR QUE FOR SELECIONADO | 30d | 2018-01-01 | 2018-01-30 | 4SS | 0d |
| 128 | 1.1.6.7 | PROJETO DE CANTEIRO DE OBRAS EM BIM LOD 300 | 30d | 2018-01-01 | 2018-01-30 | 4SS | 0d |
| 129 | 1.1.6.8 | INVENTÁRIO DE ENGENHARIA REFERENTE AS CONDIÇÕES EXISTENTES | 30d | 2018-01-01 | 2018-01-30 | 4SS | 0d |
| 130 | 1.1.6.9 | ORGANIZAÇÃO E ELABORAÇÃO DE DOCUMENTAÇÃO TÉCNICA DE OBRA, MANUAIS DE MANUTENÇÃO DO EDIFÍCIO, DOCUMENTAÇÃO DA OBRA RELATIVA A SEU CONTROLE DE QUALIDADE. | 592d | 2018-01-01 | 2019-08-15 | 4SS | 0d |
| 131 | 1.1.6.10 | PROJETO EXECULTIVO DE FORMA E CIMBRAMENTO EM BIM LOD 300 (DETALHAMENTO) | 30d | 2018-01-01 | 2018-01-30 | 4SS | 0d |
| 132 | 1.1.6.11 | AS BUILT OBRA | 30d | 2019-07-12 | 2019-08-10 | 318FF-5d | 0d |

| ID | WBS | Task | Duration | Start | Finish | Predecessors | Total slack |
| --- | --- | --- | --- | --- | --- | --- | --- |
| 133 | 1.1.7 | **EQUIPAMENTOS DE APOIO** | 592d | 2018-01-01 | 2019-08-15 |  | 0d |
| 134 | 1.1.7.1 | LOCAÇÃO DE GRUA - BLOCO B | 418d | 2018-03-26 | 2019-05-17 | 167SS | 0d |
| 135 | 1.1.7.2 | LOCAÇÃO DE GRUA - BLOCO C | 305d | 2018-03-20 | 2019-01-18 | 247SS | 0d |
| 136 | 1.1.7.3 | LOCAÇÃO DE CREMALHEIRA | 90d | 2019-05-18 | 2019-08-15 | 205 | 0d |
| 137 | 1.1.7.4 | RETROESCAVADEIRA C/ CARREGADEIRA SOBRE PNEUS 75HP C/CONVERSOR DE TORQUE (INCL MANUTENCAO/OPERACAO E COMBUSTÍVEL) | 592d | 2018-01-01 | 2019-08-15 | 4SS | 0d |
| 138 | 1.1.7.5 | MINI PA CARREGADEIRA | 592d | 2018-01-01 | 2019-08-15 | 4SS | 0d |
| 139 | 1.1.7.6 | BETONEIRA 580L ELETRICA TRIFASICA 7,5HP | 592d | 2018-01-01 | 2019-08-15 | 4SS | 0d |
| 140 | 1.1.7.7 | BETONEIRA 580L ELETRICA TRIFASICA 7,5HP | 500d | 2018-01-03 | 2019-05-17 | 232SS | 0d |
| 141 | 1.1.7.8 | MARTELETE OU ROMPEDOR PNEUMÁTICO MANUAL 28KG | 592d | 2018-01-01 | 2019-08-15 | 4SS | 0d |
| 142 | 1.1.7.9 | MOTOR PARA VIBRADOR | 500d | 2018-01-03 | 2019-05-17 | 232SS | 0d |
| 143 | 1.1.7.10 | MÁQUINA PARA CORTE DE AÇO | 592d | 2018-01-01 | 2019-08-15 | 4SS | 0d |
| 144 | 1.1.7.11 | MESA PARA DOBRA DE AÇO MANUAL | 592d | 2018-01-01 | 2019-08-15 | 4SS | 0d |
| 145 | 1.1.7.12 | SERRA CIRCULAR DE BANCADA | 592d | 2018-01-01 | 2019-08-15 | 4SS | 0d |
| 146 | 1.1.7.13 | MARTELETE ROMPEDOR | 592d | 2018-01-01 | 2019-08-15 | 4SS | 0d |
| 147 | 1.1.7.14 | MAQUINA PARA SOLDA | 592d | 2018-01-01 | 2019-08-15 | 4SS | 0d |
| 148 | 1.1.7.15 | CAMINHÃO COM MUNCK 8 T | 592d | 2018-01-01 | 2019-08-15 | 4SS | 0d |
| 149 | 1.1.7.16 | CAMINHÃO COM CARROCERIA 8T INCLUSIVE MOTORISTA | 592d | 2018-01-01 | 2019-08-15 | 4SS | 0d |
| 150 | 1.1.7.17 | TEODOLITO ELETRONICO | 592d | 2018-01-01 | 2019-08-15 | 4SS | 0d |
| 151 | 1.2 | **TERRAPLENAGEM** | 172d | 2018-01-31 | 2018-07-21 |  | 0d |
| 152 | 1.2.1 | TERRAPLENAGEM ETAPA 01 | 30d | 2018-01-31 | 2018-03-01 | 4SS+30d | 0d |
| 153 | 1.2.2 | TERRAPLENAGEM ETAPA 02 | 30d | 2018-06-22 | 2018-07-21 | 179, 258 | 0d |
| 154 | 1.3 | **BLOCO B** | 444d | 2018-02-28 | 2019-05-17 |  | 0d |
| 155 | 1.3.1 | ÁGUAS PLUVIAIS | 30d | 2018-03-26 | 2018-04-24 | 170SS, 171SS | 388d |
| 156 | 1.3.2 | IMPERMEABILIZAÇÃO | 30d | 2018-03-10 | 2018-04-08 | 174FF | 404d |
| 157 | 1.3.3 | ATERRAMENTO DA ESTRUTURA | 428d | 2018-03-02 | 2019-05-03 | 161SS | 0d |
| 158 | 1.3.4 | INFRAESTRUTURAS COMPLEMENTARES DAS INSTALAÇÕES | 404d | 2018-03-26 | 2019-05-03 | 167SS | 14d |

| ID | WBS | Task | Duration | Start | Finish | Predecessors | Total slack | Free slack |
| --- | --- | --- | --- | --- | --- | --- | --- | --- |
| 159 | 1.3.5 | **FUNDAÇÕES** | 150d | 2018-03-02 | 2018-07-29 |  | 0d |  |
| 160 | 1.3.5.1 | **FUNDAÇÕES PREDIO B** | 24d | 2018-03-02 | 2018-03-25 |  | 0d |  |
| 161 | 1.3.5.1.1 | TUBULÕES | 17d | 2018-03-02 | 2018-03-18 | 152SS+30d | 0d |  |
| 162 | 1.3.5.1.2 | BLOCOS | 7d | 2018-03-19 | 2018-03-25 | 161 | 0d |  |
| 163 | 1.3.5.2 | **RAMPA DE ACESSO EXTERNO** | 8d | 2018-07-22 | 2018-07-29 |  | 0d |  |
| 164 | 1.3.5.2.1 | TUBULÕES | 5d | 2018-07-22 | 2018-07-26 | 153 | 0d |  |
| 165 | 1.3.5.2.2 | BLOCOS | 3d | 2018-07-27 | 2018-07-29 | 164 | 0d |  |
| 166 | 1.3.6 | SERVIÇOS DE ESTRUTURAS METÁLICAS | 6d | 2018-06-22 | 2018-06-27 | 179 | 324d |  |
| 167 | 1.3.7 | **SUPERESTRUTURA** | 418d | 2018-03-26 | 2019-05-17 |  | 0d |  |
| 168 | 1.3.7.1 | **PAVIMENTO DO SUBSOLO** | 62d | 2018-03-26 | 2018-05-26 |  | 0d |  |
| 169 | 1.3.7.1.1 | PILARES | 14d | 2018-04-12 | 2018-04-25 | 171 | 382d | 0d |
| 170 | 1.3.7.1.2 | LAJES | 17d | 2018-03-26 | 2018-04-11 | 160 | 356d | 0d |
| 171 | 1.3.7.1.3 | VIGAS BALDRAMES | 17d | 2018-03-26 | 2018-04-11 | 160 | 0d |  |
| 172 | 1.3.7.1.4 | VIGAS | 17d | 2018-03-26 | 2018-04-11 | 160 | 401d |  |
| 173 | 1.3.7.1.5 | PAREDES | 20d | 2018-04-12 | 2018-05-01 | 171 | 0d |  |
| 174 | 1.3.7.1.6 | ELEVATÓRIA ÁGUAS PLUVIAIS | 14d | 2018-03-26 | 2018-04-08 | 160 | 404d | 0d |
| 175 | 1.3.7.1.7 | ESCADAS | 4d | 2018-04-28 | 2018-05-01 | 173FF | 0d |  |
| 176 | 1.3.7.1.8 | CIMBRAMENTO - FACHADEIRO | 45d | 2018-04-12 | 2018-05-26 | 170 | 356d |  |
| 177 | 1.3.7.1.9 | CIMBRAMENTO - TORRES E VIGAS | 29d | 2018-04-28 | 2018-05-26 | 175SS | 356d |  |
| 178 | 1.3.7.2 | **PAVIMENTO TÉRREO** | 386d | 2018-04-27 | 2019-05-17 |  | 0d |  |
| 179 | 1.3.7.2.1 | LAJES | 51d | 2018-05-02 | 2018-06-21 | 173 | 0d |  |
| 180 | 1.3.7.2.2 | VIGAS BALDRAMES | 51d | 2018-05-02 | 2018-06-21 | 173 | 0d |  |
| 181 | 1.3.7.2.3 | VIGAS | 51d | 2018-05-02 | 2018-06-21 | 179FF | 330d |  |
| 182 | 1.3.7.2.4 | PAREDES | 11d | 2018-06-22 | 2018-07-02 | 180 | 0d |  |
| 183 | 1.3.7.2.5 | PILARES | 11d | 2018-06-22 | 2018-07-02 | 180 | 319d |  |
| 184 | 1.3.7.2.6 | ESCADAS | 4d | 2018-06-18 | 2018-06-21 | 180FF | 330d |  |
| 185 | 1.3.7.2.7 | CIMBRAMENTO - FACHADEIRO (EXTERIOR) | 330d | 2018-06-22 | 2019-05-17 | 179 | 0d |  |
| 186 | 1.3.7.2.8 | CIMBRAMENTO - FACHADEIRO (INTERIOR) | 14d | 2018-06-22 | 2018-07-05 | 182FF+3d | 316d |  |
| 187 | 1.3.7.2.9 | CIMBRAMENTO - TORRES E VIGAS | 386d | 2018-04-27 | 2019-05-17 | 179SS-5d | 0d |  |
| 188 | 1.3.7.2.10 | CIMBRAMENTO - TORRES E VIGAS (EXISTENTE) | 335d | 2018-06-17 | 2019-05-17 | 182SS-5d | 0d |  |

Notes:
- 176: MULTIPLICAR DURAÇÃO POR QTDD UND.
- 177: MULTIPLICAR DURAÇÃO POR QTDD UND.
- 185: MULTIPLICAR DURAÇÃO POR QTDD UND.
- 186: MULTIPLICAR DURAÇÃO POR QTDD UND.
- 187: MULTIPLICAR DURAÇÃO POR QTDD UND.
- 188: MULTIPLICAR DURAÇÃO POR QTDD UND.

| ID | WBS | Task | Duration | Start | Finish | Predecessors | Total slack |
| --- | --- | --- | --- | --- | --- | --- | --- |
| 189 | 1.3.7.3 | **1º PAVIMENTO E ARQUIBANCADA** | 319d | 2018-07-03 | 2019-05-17 |  | 0d |
| 190 | 1.3.7.3.1 | PILARES | 9d | 2018-07-03 | 2018-07-11 | 182 | 0d |
| 191 | 1.3.7.3.2 | LAJES | 20d | 2018-08-31 | 2018-09-19 | 195 | 0d |
| 192 | 1.3.7.3.3 | VIGAS | 20d | 2018-08-31 | 2018-09-19 | 195 | 0d |
| 193 | 1.3.7.3.4 | PAREDES | 15d | 2018-09-20 | 2018-10-04 | 191, 192, 194 | 0d |
| 194 | 1.3.7.3.5 | ESCADAS | 4d | 2018-09-16 | 2018-09-19 | 192FF | 0d |
| 195 | 1.3.7.3.6 | RAMPAS | 50d | 2018-07-12 | 2018-08-30 | 190 | 0d |
| 196 | 1.3.7.3.7 | CIMBRAMENTO - FACHADEIRO | 240d | 2018-09-20 | 2019-05-17 | 191 | 0d |
| 197 | 1.3.7.3.8 | CIMBRAMENTO - TORRES E VIGAS | 265d | 2018-08-26 | 2019-05-17 | 191SS-5d | 0d |
| 198 | 1.3.7.4 | **2º PAVIMENTO E ARQUIBANCADA** | 230d | 2018-09-30 | 2019-05-17 |  | 0d |
| 199 | 1.3.7.4.1 | PILARES | 9d | 2018-10-26 | 2018-11-03 | 200 | 195d |
| 200 | 1.3.7.4.2 | LAJES | 21d | 2018-10-05 | 2018-10-25 | 193 | 0d |
| 201 | 1.3.7.4.3 | VIGAS | 21d | 2018-10-05 | 2018-10-25 | 193 | 0d |
| 202 | 1.3.7.4.4 | PAREDES | 76d | 2018-10-26 | 2019-01-09 | 200, 201 | 0d |
| 203 | 1.3.7.4.5 | CIMBRAMENTO METÁLICO - FACHADEIROS | 204d | 2018-10-26 | 2019-05-17 | 200 | 0d |
| 204 | 1.3.7.4.6 | CIMBRAMENTO - TORRES E VIGAS | 230d | 2018-09-30 | 2019-05-17 | 200SS-5d | 0d |
| 205 | 1.3.7.5 | **PISO DE SUSTENTAÇÃO** | 133d | 2019-01-05 | 2019-05-17 |  | 0d |
| 206 | 1.3.7.5.1 | VIGAS | 40d | 2019-01-10 | 2019-02-18 | 202 | 0d |
| 207 | 1.3.7.5.2 | PAREDES | 30d | 2019-02-19 | 2019-03-20 | 206 | 0d |
| 208 | 1.3.7.5.3 | CIMBRAMENTO - FACHADEIRO | 93d | 2019-02-14 | 2019-05-17 | 207SS-5d | 0d |
| 209 | 1.3.7.5.4 | CIMBRAMENTO - TORRES E VIGAS | 133d | 2019-01-05 | 2019-05-17 | 206SS-5d | 0d |
| 210 | 1.3.7.6 | **COBERTURA** | 63d | 2019-03-16 | 2019-05-17 |  | 0d |
| 211 | 1.3.7.6.1 | LAJES | 28d | 2019-03-21 | 2019-04-17 | 207 | 0d |
| 212 | 1.3.7.6.2 | VIGAS | 28d | 2019-03-21 | 2019-04-17 | 207 | 0d |
| 213 | 1.3.7.6.3 | PAREDES | 16d | 2019-04-18 | 2019-05-03 | 211, 212 | 0d |
| 214 | 1.3.7.6.4 | CIMBRAMENTO - FACHADEIRO | 35d | 2019-04-13 | 2019-05-17 | 213SS-5d | 0d |
| 215 | 1.3.7.6.5 | CIMBRAMENTO - TORRES E VIGAS | 63d | 2019-03-16 | 2019-05-17 | 211SS-5d | 0d |

Notes:
- 196: MULTIPLICAR DURAÇÃO POR QTDD UND.
- 197: MULTIPLICAR DURAÇÃO POR QTDD UND.
- 203: MULTIPLICAR DURAÇÃO POR QTDD UND.
- 204: MULTIPLICAR DURAÇÃO POR QTDD UND.
- 208: MULTIPLICAR DURAÇÃO POR QTDD UND.
- 209: MULTIPLICAR DURAÇÃO POR QTDD UND.
- 214: MULTIPLICAR DURAÇÃO POR QTDD UND.
- 215: MULTIPLICAR DURAÇÃO POR QTDD UND.

| ID | WBS | Task | Duration | Start | Finish | Predecessors | Total slack | Free slack |
| --- | --- | --- | --- | --- | --- | --- | --- | --- |
| 216 | 1.3.7.7 | **RAMPA DE ACESSO EXTERNO** | 159d | 2018-09-22 | 2019-02-27 |  | 79d |  |
| 217 | 1.3.7.7.1 | PILARES | 16d | 2018-09-27 | 2018-10-12 | 193SS+7d | 201d | 0d |
| 218 | 1.3.7.7.2 | LAJES | 16d | 2018-10-13 | 2018-10-28 | 217 | 201d | 0d |
| 219 | 1.3.7.7.3 | VIGAS | 16d | 2018-10-13 | 2018-10-28 | 217 | 201d |  |
| 220 | 1.3.7.7.4 | CIMBRAMENTO - FACHADEIRO | 143d | 2018-09-22 | 2019-02-11 | 217SS-5d | 95d |  |
| 221 | 1.3.7.7.5 | CIMBRAMENTO - TORRES E VIGAS | 143d | 2018-10-08 | 2019-02-27 | 218SS-5d | 79d |  |
| 222 | 1.3.8 | DEMOLIÇÃO E RECONSTRUÇÃO - SUBSOLOS | 5d | 2018-04-26 | 2018-04-30 | 169 | 382d |  |
| 223 | 1.3.9 | INTERVENÇÕES V60 | 5d | 2018-03-02 | 2018-03-06 | 159SS | 437d | 0d |
| 224 | 1.3.10 | CIMBRAMENTO - TORRES E VIGAS - INTERVENÇÕES V60 | 44d | 2018-02-28 | 2018-04-12 | 223SS-2d | 400d |  |
| 225 | 1.3.11 | CIMBRAMENTO METÁLICO - FACHADEIROS - INTERVENÇÕES V60 | 22d | 2018-02-28 | 2018-03-21 | 223SS-2d | 422d |  |
| 226 | 1.3.12 | **REFORÇO DE PILARES EXISTENTES V60 (PILARES 219 E 220)** | 39d | 2018-03-02 | 2018-04-09 |  | 403d |  |
| 227 | 1.3.12.1 | DEMOLIÇÃO | 2d | 2018-03-02 | 2018-03-03 | 160SS | 403d | 0d |
| 228 | 1.3.12.2 | MOVIMENTO DE TERRAS | 2d | 2018-03-04 | 2018-03-05 | 227 | 403d | 0d |
| 229 | 1.3.12.3 | FUNDAÇÃO | 7d | 2018-03-06 | 2018-03-12 | 228 | 403d | 0d |
| 230 | 1.3.12.4 | RECOMPOSIÇÃO LAJE SUBSOLO | 7d | 2018-03-13 | 2018-03-19 | 229 | 403d | 0d |
| 231 | 1.3.12.5 | REFORÇO PILAR | 21d | 2018-03-20 | 2018-04-09 | 230 | 403d |  |
| 232 | 1.4 | **BLOCO C** | 412d | 2018-01-03 | 2019-02-18 |  | 0d |  |
| 233 | 1.4.1 | ÁGUAS PLUVIAIS | 30d | 2018-03-16 | 2018-04-14 | 244 | 310d |  |
| 234 | 1.4.2 | IMPERMEABILIZAÇÃO | 30d | 2018-03-16 | 2018-04-14 | 244 | 310d |  |
| 235 | 1.4.3 | INFRAESTRUTURAS COMPLEMENTARES DAS INSTALAÇÕES | 310d | 2018-03-20 | 2019-01-23 | 247SS | 26d |  |
| 236 | 1.4.4 | ATERRAMENTO DA ESTRUTURA | 328d | 2018-03-02 | 2019-01-23 | 243SS | 26d |  |
| 237 | 1.4.5 | **DEMOLIÇÕES** | 15d | 2018-01-03 | 2018-01-17 |  | 0d |  |
| 238 | 1.4.5.1 | PAVIMENTO DO SUBSOLO | 5d | 2018-01-03 | 2018-01-07 | 4SS+2d | 0d |  |
| 239 | 1.4.5.2 | PAVIMENTO DO TÉRREO | 5d | 2018-01-03 | 2018-01-07 | 238SS | 397d | 0d |
| 240 | 1.4.5.3 | 1º PAVIMENTO | 10d | 2018-01-08 | 2018-01-17 | 239 | 397d |  |

Notes:
- 220: MULTIPLICAR DURAÇÃO POR QTDD UND.
- 221: MULTIPLICAR DURAÇÃO POR QTDD UND.
- 224: MULTIPLICAR DURAÇÃO POR QTDD UND.
- 225: MULTIPLICAR DURAÇÃO POR QTDD UND.

| ID | WBS | Task | Duration | Start | Finish | Predecessors | Total slack |
| --- | --- | --- | --- | --- | --- | --- | --- |
| 241 | 1.4.6 | **FUNDAÇÕES** | 18d | 2018-03-02 | 2018-03-19 |  | 0d |
| 242 | 1.4.6.1 | **FUNDAÇÕES PREDIO C** | 18d | 2018-03-02 | 2018-03-19 |  | 0d |
| 243 | 1.4.6.1.1 | TUBULÕES | 7d | 2018-03-02 | 2018-03-08 | 152 | 0d |
| 244 | 1.4.6.1.2 | BLOCOS | 7d | 2018-03-09 | 2018-03-15 | 243 | 0d |
| 245 | 1.4.6.1.3 | VIGAS BALDRAMES | 4d | 2018-03-16 | 2018-03-19 | 244 | 0d |
| 246 | 1.4.7 | SERVIÇOS DE ESTRUTURAS METÁLICAS | 3d | 2019-02-16 | 2019-02-18 | 256 | 0d |
| 247 | 1.4.8 | **SUPERESTRUTURA** | 333d | 2018-03-20 | 2019-02-15 |  | 0d |
| 248 | 1.4.8.1 | **PAVIMENTO DO SUBSOLO** | 33d | 2018-03-20 | 2018-04-21 |  | 0d |
| 249 | 1.4.8.1.1 | LAJES/VIGAS | 16d | 2018-03-20 | 2018-04-04 | 242 | 0d |
| 250 | 1.4.8.1.2 | ESCADAS | 4d | 2018-04-05 | 2018-04-08 | 249 | 0d |
| 251 | 1.4.8.1.3 | ELEVATÓRIA ÁGUAS PLUVIAIS | 6d | 2018-03-30 | 2018-04-04 | 249FF | 17d |
| 252 | 1.4.8.1.4 | PILARES | 7d | 2018-04-05 | 2018-04-11 | 249 | 10d |
| 253 | 1.4.8.1.5 | PAREDES | 14d | 2018-04-05 | 2018-04-18 | 249 | 3d |
| 254 | 1.4.8.1.6 | CIMBRAMENTO - FACHADEIRO | 17d | 2018-04-05 | 2018-04-21 | 249 | 0d |
| 255 | 1.4.8.1.7 | CIMBRAMENTO - TORRES E VIGAS | 8d | 2018-04-03 | 2018-04-10 | 250SS-2d | 0d |
| 256 | 1.4.8.2 | **PISO TÉRREO** | 305d | 2018-04-17 | 2019-02-15 |  | 0d |
| 257 | 1.4.8.2.1 | PILARES | 7d | 2018-05-12 | 2018-05-18 | 258 | 273d |
| 258 | 1.4.8.2.2 | LAJES | 20d | 2018-04-22 | 2018-05-11 | 248 | 0d |
| 259 | 1.4.8.2.3 | VIGAS | 20d | 2018-04-22 | 2018-05-11 | 248 | 0d |
| 260 | 1.4.8.2.4 | ESCADAS | 2d | 2018-05-10 | 2018-05-11 | 258FF | 0d |
| 261 | 1.4.8.2.5 | PAREDES | 20d | 2018-05-12 | 2018-05-31 | 258, 259, 260 | 260d |
| 262 | 1.4.8.2.6 | MUROS DE ARRIMO DE CONCRETO | 20d | 2018-05-12 | 2018-05-31 | 258, 259, 260 | 0d |
| 263 | 1.4.8.2.7 | CIMBRAMENTO - FACHADEIRO (EXTERIOR) | 260d | 2018-06-01 | 2019-02-15 | 262 | 0d |
| 264 | 1.4.8.2.8 | CIMBRAMENTO - FACHADEIRO (INTERIOR) | 40d | 2018-04-17 | 2018-05-26 | 258SS-5d | 265d |
| 265 | 1.4.8.2.9 | CIMBRAMENTO - TORRES E VIGAS | 40d | 2018-04-17 | 2018-05-26 | 258SS-5d | 265d |

Notes:
- 254: MULTIPLICAR DURAÇÃO POR QTDD UND.
- 255: MULTIPLICAR DURAÇÃO POR QTDD UND.
- 263: MULTIPLICAR DURAÇÃO POR QTDD UND.
- 264: MULTIPLICAR DURAÇÃO POR QTDD UND.
- 265: MULTIPLICAR DURAÇÃO POR QTDD UND.

| ID | WBS | Task | Duration | Start | Finish | Predecessors | Total slack | Free slack |
| --- | --- | --- | --- | --- | --- | --- | --- | --- |
| 266 | 1.4.8.3 | **1º PAVIMENTO** | 270d | 2018-05-22 | 2019-02-15 |  | 0d |  |
| 267 | 1.4.8.3.1 | PILARES | 10d | 2018-05-22 | 2018-05-31 | 262SS+10d | 0d |  |
| 268 | 1.4.8.3.2 | LAJES | 20d | 2018-06-01 | 2018-06-20 | 267 | 0d |  |
| 269 | 1.4.8.3.3 | VIGAS | 20d | 2018-06-01 | 2018-06-20 | 268FF | 0d |  |
| 270 | 1.4.8.3.4 | PAREDES | 15d | 2018-06-21 | 2018-07-05 | 259, 269 | 0d |  |
| 271 | 1.4.8.3.5 | ESCADAS | 4d | 2018-06-17 | 2018-06-20 | 268FF | 240d |  |
| 272 | 1.4.8.3.6 | CIMBRAMENTO - FACHADEIRO (EXTERIOR) | 265d | 2018-05-27 | 2019-02-15 | 268SS-5d | 0d |  |
| 273 | 1.4.8.3.7 | CIMBRAMENTO - FACHADEIRO (INTERIOR) | 50d | 2018-06-16 | 2018-08-04 | 270SS-5d | 195d |  |
| 274 | 1.4.8.3.8 | CIMBRAMENTO - TORRES E VIGAS | 265d | 2018-05-27 | 2019-02-15 | 268SS-5d | 0d |  |
| 275 | 1.4.8.4 | **2º PAVIMENTO E NÍVEL INTERMÉDIO ETAPA 01** | 230d | 2018-07-01 | 2019-02-15 |  | 0d |  |
| 276 | 1.4.8.4.1 | LAJES | 53d | 2018-07-06 | 2018-08-27 | 270 | 0d |  |
| 277 | 1.4.8.4.2 | VIGAS | 53d | 2018-07-06 | 2018-08-27 | 276FF | 172d |  |
| 278 | 1.4.8.4.3 | ESCADAS | 4d | 2018-08-24 | 2018-08-27 | 276FF | 172d | 0d |
| 279 | 1.4.8.4.4 | CIMBRAMENTO - FACHADEIRO (EXTERIOR) | 230d | 2018-07-01 | 2019-02-15 | 276SS-5d | 0d |  |
| 280 | 1.4.8.4.5 | CIMBRAMENTO - FACHADEIRO (INTERIOR) | 20d | 2018-08-19 | 2018-09-07 | 278SS-5d | 161d |  |
| 281 | 1.4.8.4.6 | CIMBRAMENTO - TORRES E VIGAS | 225d | 2018-07-06 | 2019-02-15 | 276SS | 0d |  |
| 282 | 1.4.8.5 | **2º PAVIMENTO E NÍVEL INTERMÉDIO ETAPA 02** | 177d | 2018-08-23 | 2019-02-15 |  | 0d |  |
| 283 | 1.4.8.5.1 | LAJES | 26d | 2018-08-28 | 2018-09-22 | 276 | 0d |  |
| 284 | 1.4.8.5.2 | VIGAS | 26d | 2018-08-28 | 2018-09-22 | 283FF | 146d |  |
| 285 | 1.4.8.5.3 | CIMBRAMENTO - TORRES E VIGAS | 177d | 2018-08-23 | 2019-02-15 | 283SS-5d | 0d |  |
| 286 | 1.4.8.6 | **2º PAVIMENTO E NÍVEL INTERMÉDIO ETAPA 03** | 151d | 2018-09-18 | 2019-02-15 |  | 0d |  |
| 287 | 1.4.8.6.1 | PILARES | 10d | 2018-10-16 | 2018-10-25 | 288FF+7d | 113d |  |
| 288 | 1.4.8.6.2 | LAJES | 26d | 2018-09-23 | 2018-10-18 | 283 | 0d |  |
| 289 | 1.4.8.6.3 | VIGAS | 26d | 2018-09-23 | 2018-10-18 | 288FF | 120d |  |
| 290 | 1.4.8.6.4 | PAREDES | 10d | 2018-10-16 | 2018-10-25 | 288FF+7d | 0d |  |
| 291 | 1.4.8.6.5 | CIMBRAMENTO - TORRES E VIGAS | 151d | 2018-09-18 | 2019-02-15 | 288SS-5d | 0d |  |

Notes:
- 272: MULTIPLICAR DURAÇÃO POR QTDD UND.
- 273: MULTIPLICAR DURAÇÃO POR QTDD UND.
- 274: MULTIPLICAR DURAÇÃO POR QTDD UND.
- 279: MULTIPLICAR DURAÇÃO POR QTDD UND.
- 280: MULTIPLICAR DURAÇÃO POR QTDD UND.
- 281: MULTIPLICAR DURAÇÃO POR QTDD UND.
- 285: MULTIPLICAR DURAÇÃO POR QTDD UND.
- 291: MULTIPLICAR DURAÇÃO POR QTDD UND.

| ID | WBS | Task | Duration | Start | Finish | Predecessors | Total slack |
| --- | --- | --- | --- | --- | --- | --- | --- |
| 292 | 1.4.8.7 | **NÍVEL INTERMÉDIO/RAMPA** | 128d | 2018-10-11 | 2019-02-15 |  | 0d |
| 293 | 1.4.8.7.1 | LAJES | 15d | 2018-10-16 | 2018-10-30 | 290SS | 0d |
| 294 | 1.4.8.7.2 | VIGAS | 15d | 2018-10-16 | 2018-10-30 | 293FF | 108d |
| 295 | 1.4.8.7.3 | CIMBRAMENTO - TORRES E VIGAS | 128d | 2018-10-11 | 2019-02-15 | 293SS-5d | 0d |
| 296 | 1.4.8.8 | **COBERTURA ETAPA 01** | 128d | 2018-10-11 | 2019-02-15 |  | 0d |
| 297 | 1.4.8.8.1 | LAJES | 26d | 2018-10-31 | 2018-11-25 | 293 | 0d |
| 298 | 1.4.8.8.2 | VIGAS | 26d | 2018-10-31 | 2018-11-25 | 297FF | 82d |
| 299 | 1.4.8.8.3 | CIMBRAMENTO - FACHADEIRO (EXTERIOR) | 128d | 2018-10-11 | 2019-02-15 | 297SS-20d | 0d |
| 300 | 1.4.8.8.4 | CIMBRAMENTO - FACHADEIRO (INTERIOR) | 51d | 2018-10-26 | 2018-12-15 | 297SS-5d | 62d |
| 301 | 1.4.8.8.5 | CIMBRAMENTO - TORRES E VIGAS | 66d | 2018-10-11 | 2018-12-15 | 297SS-20d | 62d |
| 302 | 1.4.8.9 | **COBERTURA ETAPA 02** | 97d | 2018-11-11 | 2019-02-15 |  | 0d |
| 303 | 1.4.8.9.1 | LAJES | 26d | 2018-11-26 | 2018-12-21 | 297 | 0d |
| 304 | 1.4.8.9.2 | VIGAS | 26d | 2018-11-26 | 2018-12-21 | 303FF | 56d |
| 305 | 1.4.8.9.3 | CIMBRAMENTO - TORRES E VIGAS | 97d | 2018-11-11 | 2019-02-15 | 303SS-15d | 0d |
| 306 | 1.4.8.10 | **COBERTURA ETAPA 03** | 66d | 2018-12-12 | 2019-02-15 |  | 0d |
| 307 | 1.4.8.10.1 | LAJES | 26d | 2018-12-22 | 2019-01-16 | 303 | 0d |
| 308 | 1.4.8.10.2 | VIGAS | 26d | 2018-12-22 | 2019-01-16 | 307FF | 30d |
| 309 | 1.4.8.10.3 | PAREDES | 8d | 2019-01-16 | 2019-01-23 | 307FF+7d | 23d |
| 310 | 1.4.8.10.4 | CIMBRAMENTO - TORRES E VIGAS | 66d | 2018-12-12 | 2019-02-15 | 307SS-10d | 0d |
| 311 | 1.4.9 | REFORÇO PA1-PA2-PA6-PA7 - MOVIMENTO DE TERRAS - BLOCO C | 30d | 2018-01-31 | 2018-03-01 | 152SS | 0d |
| 312 | 1.4.10 | REFORÇO PILARES PA1-PA2-PA6-PA7 | 10d | 2018-03-19 | 2018-03-28 | 314 | 0d |
| 313 | 1.4.11 | CIMBRAMENTO - FACHADEIRO - REFORÇO PILARES PA1-PA2-PA6-PA7 | 15d | 2018-03-19 | 2018-04-02 | 312SS | 322d |
| 314 | 1.4.12 | REFORÇO BLOCOS PILARES PA1-PA2-PA6-PA7 | 7d | 2018-03-12 | 2018-03-18 | 315 | 0d |
| 315 | 1.4.13 | REFORÇO TUBULÕES PILARES PA2-PA6-PA7 | 10d | 2018-03-02 | 2018-03-11 | 311 | 0d |

Notes:
- 295: MULTIPLICAR DURAÇÃO POR QTDD UND.
- 299: MULTIPLICAR DURAÇÃO POR QTDD UND.
- 300: MULTIPLICAR DURAÇÃO POR QTDD UND.
- 301: MULTIPLICAR DURAÇÃO POR QTDD UND.
- 305: MULTIPLICAR DURAÇÃO POR QTDD UND.
- 310: MULTIPLICAR DURAÇÃO POR QTDD UND.
- 312: MULTIPLICAR DURAÇÃO POR QTDD UND.
- 313: MULTIPLICAR DURAÇÃO POR QTDD UND.

| ID | WBS | Task | Duration | Start | Finish | Predecessors | Total slack |
| --- | --- | --- | --- | --- | --- | --- | --- |
| 316 | 1.4.14 | **TUBULÕES DE INSPECÇÃO** | 7d | 2018-03-02 | 2018-03-08 |  | 347d |
| 317 | 1.4.14.1 | SERVIÇOS DE INSPECÇÃO DO SOLO NA BASE DAS FUNDAÇÕES DO PA7 E TUBULÕES | 7d | 2018-03-02 | 2018-03-08 | 242SS | 347d |
| 318 | 1.5 | SERVIÇOS FINAIS | 90d | 2019-05-18 | 2019-08-15 | 167 | 0d |
